# SUBPROYECTO A1

Schedule from Primavera P6, 2023-12-01 to 2024-06-03, data date 2023-12-01.
Must finish by 2024-06-03

## Calendars

- 1T - 7x0 - 8 hr: Mon-Sun 08:00-16:00.

## Resources

| Resource | Group |
| --- | --- |
| HH | labor |

## Schedule

| ID | WBS | Activity | Type | Duration | Start | Finish | Predecessors | Total float | Free float | Resources | Filtro |
| --- | --- | --- | --- | --- | --- | --- | --- | --- | --- | --- | --- |
|  | 0 | **HITOS** |  |  | 2023-12-01 | 2024-06-03 |  |  |  |  |  |
| A1015 |  | INICIO DE PLAZO CONTRACTUAL - ACCESO AL SITIO | milestone | 0d | 2023-12-01 | 2023-12-01 |  | 0d |  |  |  |
| A4240 |  | INICIO DE EXCAVACIÓN | milestone | 0d | 2023-12-21 | 2023-12-21 | A1015 SS+20d | 0d |  |  |  |
| A1016 |  | INICIO DE RELLENO DE DIQUE | milestone | 0d | 2024-01-12 | 2024-01-12 | A4240 SS+22d | 36d | 16d |  |  |
| A1020 |  | FIN DE PLAZO CONTRACTUAL | milestone | 0d | 2024-06-03 | 2024-06-03 | A1780, A1070, A1050, A3530, A3470 FF, A2800 FF, A6760 FF, A7550 FF, A7390 FF, A1080 FF, A1770 FF | 0d |  |  |  |
|  | 1 | **DEFENSAS RIBEREÑAS** |  |  | 2023-12-01 | 2024-06-03 |  |  |  |  |  |
|  | 1 | **OBRAS PRELIMINARES** |  |  | 2023-12-03 | 2024-05-27 |  |  |  |  |  |
| A1030 |  | CARTEL DE IDENTIFICACIÓN OBRA 4.80 x 3.60 m. |  | 2d | 2023-12-03 | 2023-12-04 | A1015 SS+2d | 7d | 0d | HH [16 h] |  |
| A1040 |  | INSTALACIONES PROVISIONALES PARA LA OBRA |  | 17d | 2023-12-04 | 2023-12-20 | A1015 SS, A1030 SS+1d | 7d | 0d | HH [136 h] |  |
| A1050 |  | MANTENIMIENTO DE TRÁNSITO Y SEGURIDAD VIAL |  | 160d | 2023-12-20 | 2024-05-27 | A1040 SS+16d | 7d |  | HH [1280 h] |  |
|  | 2 | **TRABAJOS PRELIMINARES** |  |  | 2023-12-01 | 2024-06-03 |  |  |  |  |  |
| A1060 |  | MOVILIZACION DE EQUIPOS |  | 26d | 2023-12-01 | 2023-12-26 |  | 3d | 0d | HH [208 h] |  |
| A1070 |  | TOPOGRAFÍA Y GEOREFERENCIACIÓN |  | 156d | 2023-12-28 | 2024-05-31 | A1040, A1060 FS+1d | 3d |  | HH [1248 h] |  |
| A1080 |  | DESMOVILIZACION DE EQUIPOS |  | 9d | 2024-05-26 | 2024-06-03 | A7280 SS | 0d |  | HH [72 h] |  |
|  | 3 | **MEJORAMIENTO DE VÍAS EXISTENTES** |  |  | 2023-12-18 | 2023-12-20 |  |  |  |  |  |
|  | 1 | **MOVIMIENTO DE TIERRAS** |  |  | 2023-12-18 | 2023-12-20 |  |  |  |  |  |
| A1100 |  | REHABILITACIÓN DE VÍAS EXISTENTES |  | 3d | 2023-12-18 | 2023-12-20 | A1040 SS+14d | 166d | 163d | HH [24 h] |  |
|  | 4 | **DESCOLMATACIÓN DE CAUCE Y OBRAS AUXILIARES** |  |  | 2023-12-21 | 2024-04-26 |  |  |  |  |  |
|  | 1 | **DESBROCE Y DESCOLMATACIÓN** |  |  | 2023-12-21 | 2024-04-26 |  |  |  |  |  |
| A1220 |  | DESBROCE Y LIMPIEZA EN ZONA NO BOSCOSA |  | 52d | 2023-12-21 | 2024-02-10 | A4240 SS | 3d | 0d | HH [416 h] | Excavación |
| A5410 |  | DESCOLMATACIÓN DE CAUCE NATURAL DEL RÍO LACRAMARCA |  | 101d | 2023-12-24 | 2024-04-02 | A1220 SS+3d | 38d | 0d | HH [808 h] | Excavación |
| A1890 |  | CONFORMACIÓN DE DESVIO EN CAUCE DE RÍO |  | 120d | 2023-12-29 | 2024-04-26 | A5410 SS+5d | 38d | 61d | HH [960 h] | Excavación |
|  | 5 | **DIQUES DE TIERRA COMPACTADA CON ENROCADO** |  |  | 2023-12-21 | 2024-05-31 |  |  |  |  |  |
|  | 3 | **DIQUE A1-I-2** |  |  | 2023-12-21 | 2024-02-05 |  |  |  |  |  |
|  | 10 | **DIQUE DE TIERRA COMPACTADA A1-I-2 LIBERADO** |  |  | 2023-12-21 | 2024-02-05 |  |  |  |  |  |
| A7510 |  | ENTREGA DE TERRENO LIBERADO DE INTERFERENCIAS - RESTRICCIONES |  | 0d | 2023-12-21 | 2023-12-21 | A4240 SS | 0d |  |  |  |
| A6850 |  | EXCAVACIÓN EN TERRENO NATURAL CON EQUIPO |  | 34d | 2023-12-22 | 2024-01-24 | A7510 FS+1d, A4240 SS | 0d |  | HH [272 h] | Excavación |
| A6900 |  | CONFORMACIÓN DE CUERPO DE DIQUE CON MATERIAL PRESTADO |  | 13d | 2024-01-14 | 2024-01-26 | A6860 FF+1d | 3d | 0d | HH [104 h] | Relleno |
| A6860 |  | PERFILADO Y COMPACTACIÓN EN ZONA DE CORTE |  | 11d | 2024-01-15 | 2024-01-25 | A6850 FF+1d | 0d |  | HH [88 h] |  |
| A6870 |  | EXCAVACIÓN DE UÑA CON EQUIPO |  | 9d | 2024-01-19 | 2024-01-27 | A6850 SS, A6860 FF+2d | 0d |  | HH [72 h] | Excavación |
| A6890 |  | PEDRAPLÉN e=60 cm |  | 10d | 2024-01-20 | 2024-01-29 | A6860 FF+1d, A6870 SS+1d | 0d |  | HH [80 h] |  |
| A6910 |  | CONFORMACIÓN DE RELLENO NO ESTRUCTURAL CON MATERIAL PROPIO |  | 6d | 2024-01-21 | 2024-01-26 | A6900 FF | 4d |  | HH [48 h] | Relleno |
| A6880 |  | PEDRAPLÉN e=30 cm |  | 8d | 2024-01-23 | 2024-01-30 | A6890 FF+1d | 0d |  | HH [64 h] |  |
| A6920 |  | GEOTEXTIL NO TEJIDO 400 G/M2, INC. COLOCACIÓN |  | 8d | 2024-01-25 | 2024-02-01 | A6910 FF+2d, A6880 SS+2d | 0d |  | HH [64 h] |  |
| A6930 |  | CONFORMACIÓN DE MATERIAL GRANULAR EN CORONA DE DIQUE |  | 4d | 2024-01-29 | 2024-02-01 | A6920 FF | 0d |  | HH [32 h] | Relleno |
| A6940 |  | COLOCACION Y ACOMODO DE ROCA EN UÑA DE DIQUE |  | 3d | 2024-01-30 | 2024-02-01 | A6930 FF | 0d |  | HH [24 h] | Roca |
| A6950 |  | COLOCACION Y ACOMODO DE ROCA EN TALUD DE DIQUE |  | 6d | 2024-01-31 | 2024-02-05 | A6940 SS+1d | 0d |  | HH [48 h] | Roca |

| ID | WBS | Activity | Duration | Start | Finish | Predecessors | Total float | Free float | Resources | Filtro |
| --- | --- | --- | --- | --- | --- | --- | --- | --- | --- | --- |
|  | 4 | **DIQUE A1-D-02** |  | 2024-02-06 | 2024-03-17 |  |  |  |  |  |
|  | 22 | **DIQUE DE TIERRA COMPACTADA A1-D-02 LIBERADO** |  | 2024-02-06 | 2024-03-17 |  |  |  |  |  |
| A7580 |  | ENTREGA DE TERRENO LIBERADO DE INTERFERENCIAS - RESTRICCIONES | 0d | 2024-02-06 | 2024-02-06 | A6950 | 0d |  |  |  |
| A5780 |  | EXCAVACIÓN EN TERRENO NATURAL CON EQUIPO | 28d | 2024-02-07 | 2024-03-05 | A7580 FS+1d | 0d |  | HH [224 h] | Excavación |
| A6100 |  | PERFILADO Y COMPACTACIÓN EN ZONA DE CORTE | 10d | 2024-02-26 | 2024-03-06 | A5780 FF+1d | 0d |  | HH [80 h] |  |
| A5790 |  | EXCAVACIÓN DE UÑA CON EQUIPO | 9d | 2024-02-29 | 2024-03-08 | A5780 SS, A6100 FF+2d | 0d |  | HH [72 h] | Excavación |
| A5870 |  | PEDRAPLÉN e=30 cm | 10d | 2024-02-29 | 2024-03-09 | A6100 FF+1d, A5880 FF, A5790 FF+1d | 0d |  | HH [80 h] |  |
| A5880 |  | PEDRAPLÉN e=60 cm | 10d | 2024-02-29 | 2024-03-09 | A6100 FF+3d | 0d |  | HH [80 h] |  |
| A5820 |  | CONFORMACIÓN DE CUERPO DE DIQUE CON MATERIAL PRESTADO | 14d | 2024-03-01 | 2024-03-14 | A5880 SS+1d, A5870 SS+1d, A1890 SS+2d | 0d |  | HH [112 h] | Relleno |
| A5830 |  | GEOTEXTIL NO TEJIDO 400 G/M2, INC. COLOCACIÓN | 9d | 2024-03-04 | 2024-03-12 | A5860 FF+2d | 0d |  | HH [72 h] |  |
| A5860 |  | CONFORMACIÓN DE RELLENO NO ESTRUCTURAL CON MATERIAL PROPIO | 5d | 2024-03-06 | 2024-03-10 | A5820 SS+5d | 0d |  | HH [40 h] | Relleno |
| A6840 |  | CONFORMACIÓN DE MATERIAL GRANULAR EN CORONA DE DIQUE | 5d | 2024-03-09 | 2024-03-13 | A5830 FF+1d | 0d |  | HH [40 h] | Relleno |
| A5840 |  | COLOCACION Y ACOMODO DE ROCA EN UÑA DE DIQUE | 5d | 2024-03-10 | 2024-03-14 | A6840 FF+1d | 0d |  | HH [40 h] | Roca |
| A5850 |  | COLOCACION Y ACOMODO DE ROCA EN TALUD DE DIQUE | 6d | 2024-03-12 | 2024-03-17 | A5840 SS+2d | 0d |  | HH [48 h] | Roca |
|  | 2 | **DIQUE A1-I-01** |  | 2024-01-05 | 2024-04-21 |  |  |  |  |  |
|  | 8 | **DIQUE DE TIERRA COMPACTADA A1-I-01 - LIBERADO** |  | 2024-01-05 | 2024-03-10 |  |  |  |  |  |
| A7590 |  | ENTREGA DE TERRENO LIBERADO DE INTERFERENCIAS - RESTRICCIONES | 0d | 2024-01-05 | 2024-01-05 | A4240 SS+15d | 20d | 0d |  |  |
| A7070 |  | EXCAVACIÓN EN TERRENO NATURAL CON EQUIPO | 47d | 2024-01-06 | 2024-02-21 | A7590 FS+1d, A4240 SS | 20d | 0d | HH [376 h] | Excavación |
| A7080 |  | PERFILADO Y COMPACTACIÓN EN ZONA DE CORTE | 41d | 2024-01-14 | 2024-02-23 | A7070 FF+2d | 20d | 0d | HH [328 h] |  |
| A7090 |  | EXCAVACIÓN DE UÑA CON EQUIPO | 35d | 2024-01-22 | 2024-02-25 | A7070 SS, A7080 FF+2d | 20d | 0d | HH [280 h] | Excavación |
| A7100 |  | PEDRAPLÉN e=60 cm | 34d | 2024-01-24 | 2024-02-26 | A7080 FF+1d, A7090 FF+1d | 20d | 0d | HH [272 h] |  |
| A7120 |  | CONFORMACIÓN DE CUERPO DE DIQUE CON MATERIAL PRESTADO | 31d | 2024-01-28 | 2024-02-27 | A7100 SS+1d, A7110 FF+1d, A1016 SS | 20d | 0d | HH [248 h] | Relleno |
| A7110 |  | PEDRAPLÉN e=30 cm | 14d | 2024-02-13 | 2024-02-26 | A7100 FF | 20d | 0d | HH [112 h] |  |
| A7140 |  | GEOTEXTIL NO TEJIDO 400 G/M2, INC. COLOCACIÓN | 17d | 2024-02-13 | 2024-02-29 | A7130 FF | 20d | 0d | HH [136 h] |  |
| A7150 |  | CONFORMACIÓN DE MATERIAL GRANULAR EN CORONA DE DIQUE | 9d | 2024-02-13 | 2024-02-21 | A7140 SS | 20d | 0d | HH [72 h] | Relleno |
| A7130 |  | CONFORMACIÓN DE RELLENO NO ESTRUCTURAL CON MATERIAL PROPIO | 13d | 2024-02-17 | 2024-02-29 | A7120 SS+20d | 20d | 0d | HH [104 h] | Relleno |
| A7160 |  | COLOCACION Y ACOMODO DE ROCA EN UÑA DE DIQUE | 17d | 2024-02-20 | 2024-03-07 | A7120 SS, A7150 SS+7d | 20d | 0d | HH [136 h] | Roca |
| A7170 |  | COLOCACION Y ACOMODO DE ROCA EN TALUD DE DIQUE | 18d | 2024-02-22 | 2024-03-10 | A7160 SS+2d | 20d | 0d | HH [144 h] | Roca |

| ID | WBS | Activity | Duration | Start | Finish | Predecessors | Total float | Free float | Resources | Filtro |
| --- | --- | --- | --- | --- | --- | --- | --- | --- | --- | --- |
|  | 15 | **DIQUE DE TIERRA COMPACTADA A1-I-01 - POR LIBERAR (1+709 AL 1+912)** |  | 2024-03-18 | 2024-04-21 |  |  |  |  |  |
| A7600 |  | ENTREGA DE TERRENO LIBERADO DE INTERFERENCIAS - RESTRICCIONES | 0d | 2024-03-18 | 2024-03-18 | A5850 | 0d |  |  |  |
| A7290 |  | EXCAVACIÓN EN TERRENO NATURAL CON EQUIPO | 17d | 2024-03-19 | 2024-04-04 | A7600 FS+1d | 0d |  | HH [136 h] | Excavación |
| A7310 |  | EXCAVACIÓN DE UÑA CON EQUIPO | 9d | 2024-03-30 | 2024-04-07 | A7290 SS, A7300 FF | 7d |  | HH [72 h] | Excavación |
| A7300 |  | PERFILADO Y COMPACTACIÓN EN ZONA DE CORTE | 8d | 2024-03-31 | 2024-04-07 | A7290 FF+3d | 0d |  | HH [64 h] |  |
| A7330 |  | PEDRAPLÉN e=60 cm | 4d | 2024-04-06 | 2024-04-09 | A7300 FF+2d, A7310 SS | 0d |  | HH [32 h] |  |
| A7320 |  | PEDRAPLÉN e=30 cm | 3d | 2024-04-07 | 2024-04-09 | A7300 FF+1d, A7330 FF | 0d |  | HH [24 h] |  |
| A7340 |  | CONFORMACIÓN DE CUERPO DE DIQUE CON MATERIAL PRESTADO | 6d | 2024-04-08 | 2024-04-13 | A7330 SS+1d, A7320 SS+1d | 0d |  | HH [48 h] | Relleno |
| A7360 |  | GEOTEXTIL NO TEJIDO 400 G/M2, INC. COLOCACIÓN | 6d | 2024-04-11 | 2024-04-16 | A7350 FF+3d | 0d |  | HH [48 h] |  |
| A7350 |  | CONFORMACIÓN DE RELLENO NO ESTRUCTURAL CON MATERIAL PROPIO | 2d | 2024-04-12 | 2024-04-13 | A7340 FF | 0d |  | HH [16 h] | Relleno |
| A7370 |  | CONFORMACIÓN DE MATERIAL GRANULAR EN CORONA DE DIQUE | 2d | 2024-04-16 | 2024-04-17 | A7360 FF+1d | 0d |  | HH [16 h] | Relleno |
| A7380 |  | COLOCACION Y ACOMODO DE ROCA EN UÑA DE DIQUE | 3d | 2024-04-18 | 2024-04-20 | A7370 FF+3d | 0d |  | HH [24 h] | Roca |
| A7390 |  | COLOCACION Y ACOMODO DE ROCA EN TALUD DE DIQUE | 3d | 2024-04-19 | 2024-04-21 | A7380 SS+1d | 0d |  | HH [24 h] | Roca |
|  | 1 | **DIQUE A1-D-01** |  | 2024-03-11 | 2024-05-31 |  |  |  |  |  |
|  | 18 | **DIQUE DE TIERRA COMPACTADA A1-D-01 - LIBERADO** |  | 2024-03-11 | 2024-05-03 |  |  |  |  |  |
| A7610 |  | ENTREGA DE TERRENO LIBERADO DE INTERFERENCIAS - RESTRICCIONES | 0d | 2024-03-11 | 2024-03-11 | A7170 | 25d | 0d |  |  |
| A6960 |  | EXCAVACIÓN EN TERRENO NATURAL CON EQUIPO | 34d | 2024-03-12 | 2024-04-14 | A7610 FS+1d | 25d | 0d | HH [272 h] | Excavación |
| A6970 |  | PERFILADO Y COMPACTACIÓN EN ZONA DE CORTE | 31d | 2024-03-18 | 2024-04-17 | A6960 FF+3d | 25d | 0d | HH [248 h] |  |
| A6980 |  | EXCAVACIÓN DE UÑA CON EQUIPO | 30d | 2024-03-21 | 2024-04-19 | A6960 SS, A6970 FF+2d | 27d | 2d | HH [240 h] | Excavación |
| A7000 |  | PEDRAPLÉN e=60 cm | 30d | 2024-03-23 | 2024-04-21 | A6970 SS+5d, A6980 SS | 25d | 0d | HH [240 h] |  |
| A6990 |  | PEDRAPLÉN e=30 cm | 12d | 2024-03-25 | 2024-04-05 | A7000 SS+2d | 41d | 16d | HH [96 h] |  |
| A7010 |  | CONFORMACIÓN DE CUERPO DE DIQUE CON MATERIAL PRESTADO | 27d | 2024-03-27 | 2024-04-22 | A7000 FF+1d, A6990 FF+1d | 25d | 0d | HH [216 h] | Relleno |
| A7020 |  | CONFORMACIÓN DE RELLENO NO ESTRUCTURAL CON MATERIAL PROPIO | 21d | 2024-04-04 | 2024-04-24 | A7010 FF+2d | 25d | 0d | HH [168 h] | Relleno |
| A7030 |  | GEOTEXTIL NO TEJIDO 400 G/M2, INC. COLOCACIÓN | 19d | 2024-04-08 | 2024-04-26 | A7020 FF+2d | 25d | 0d | HH [152 h] |  |
| A7040 |  | CONFORMACIÓN DE MATERIAL GRANULAR EN CORONA DE DIQUE | 20d | 2024-04-10 | 2024-04-29 | A7030 SS+2d | 25d | 0d | HH [160 h] | Relleno |
| A7050 |  | COLOCACION Y ACOMODO DE ROCA EN UÑA DE DIQUE | 14d | 2024-04-18 | 2024-05-01 | A7040 FF+2d | 31d | 0d | HH [112 h] | Roca |
| A7060 |  | COLOCACION Y ACOMODO DE ROCA EN TALUD DE DIQUE | 14d | 2024-04-20 | 2024-05-03 | A7050 SS+2d | 31d | 28d | HH [112 h] | Roca |

| ID | WBS | Activity | Duration | Start | Finish | Predecessors | Total float | Free float | Resources | Filtro |
| --- | --- | --- | --- | --- | --- | --- | --- | --- | --- | --- |
|  | 17 | **DIQUE DE TIERRA COMPACTADA A1-D-01 - POR LIBERAR (1+709 AL 1+912 Y DEL KM 2+533 AL 2+737)** |  | 2024-04-22 | 2024-05-31 |  |  |  |  |  |
| A7620 |  | ENTREGA DE TERRENO LIBERADO DE INTERFERENCIAS - RESTRICCIONES | 0d | 2024-04-22 | 2024-04-22 | A7390 | 0d |  |  |  |
| A7180 |  | EXCAVACIÓN EN TERRENO NATURAL CON EQUIPO | 29d | 2024-04-23 | 2024-05-21 | A7620 FS+1d | 0d |  | HH [232 h] | Excavación |
| A7190 |  | PERFILADO Y COMPACTACIÓN EN ZONA DE CORTE | 15d | 2024-05-10 | 2024-05-24 | A7180 FF+3d | 0d |  | HH [120 h] |  |
| A7230 |  | CONFORMACIÓN DE CUERPO DE DIQUE CON MATERIAL PRESTADO | 12d | 2024-05-14 | 2024-05-25 | A7190 FF+1d | 0d |  | HH [96 h] | Relleno |
| A7200 |  | EXCAVACIÓN DE UÑA CON EQUIPO | 9d | 2024-05-16 | 2024-05-24 | A7180 SS, A7190 FF | 10d | 7d | HH [72 h] | Excavación |
| A7250 |  | GEOTEXTIL NO TEJIDO 400 G/M2, INC. COLOCACIÓN | 12d | 2024-05-17 | 2024-05-28 | A7240 FF+2d | 0d |  | HH [96 h] |  |
| A7220 |  | PEDRAPLÉN e=60 cm | 6d | 2024-05-21 | 2024-05-26 | A7190 FF+1d, A7230 FF+1d | 3d | 0d | HH [48 h] |  |
| A7240 |  | CONFORMACIÓN DE RELLENO NO ESTRUCTURAL CON MATERIAL PROPIO | 6d | 2024-05-21 | 2024-05-26 | A7230 FF+1d | 0d |  | HH [48 h] | Relleno |
| A7260 |  | CONFORMACIÓN DE MATERIAL GRANULAR EN CORONA DE DIQUE | 4d | 2024-05-21 | 2024-05-24 | A7250 SS+4d | 0d |  | HH [32 h] | Relleno |
| A7270 |  | COLOCACION Y ACOMODO DE ROCA EN UÑA DE DIQUE | 6d | 2024-05-22 | 2024-05-27 | A7260 FF+3d | 0d |  | HH [48 h] | Roca |
| A7280 |  | COLOCACION Y ACOMODO DE ROCA EN TALUD DE DIQUE | 4d | 2024-05-26 | 2024-05-29 | A7270 SS+4d | 0d |  | HH [32 h] | Roca |
| A7210 |  | PEDRAPLÉN e=30 cm | 2d | 2024-05-30 | 2024-05-31 | A7220 FF+5d | 3d | 2d | HH [16 h] |  |
|  | 6 | **RAMPAS** |  | 2024-01-27 | 2024-05-07 |  |  |  |  |  |
|  | 1 | **CONSTRUCCION DE RAMPAS** |  | 2024-01-27 | 2024-05-07 |  |  |  |  |  |
| A6660 |  | EXCAVACIÓN EN TERRENO NATURAL CON EQUIPO | 96d | 2024-01-27 | 2024-05-01 | A6900 | 27d | 0d | HH [768 h] |  |
| A7400 |  | CONFORMACIÓN DE CUERPO DE RAMPA CON MATERIAL DE PRESTAMO | 97d | 2024-01-29 | 2024-05-04 | A6660 SS+2d | 27d | 0d | HH [776 h] |  |
| A7410 |  | CONFORMACIÓN DE MATERIAL GRANULAR EN CORONA | 97d | 2024-02-01 | 2024-05-07 | A7400 SS+3d | 27d | 24d | HH [776 h] |  |
|  | 5 | **TRANSPORTE** |  | 2023-12-22 | 2024-05-31 |  |  |  |  |  |
|  | 1 | **TRANSPORTE 1<km // 1>km** |  | 2023-12-22 | 2024-05-31 |  |  |  |  |  |
| A7450 |  | TRANSPORTE DE MATERIAL EXCEDENTE PARA DISTANCIAS <1KM | 162d | 2023-12-22 | 2024-05-31 | A6850 SS | 3d | 0d | HH [1296 h] |  |
| A7460 |  | TRANSPORTE DE MATERIAL EXCEDENTE PARA DISTANCIAS >1KM | 162d | 2023-12-22 | 2024-05-31 | A7450 SS | 3d | 0d | HH [1296 h] |  |
| A6830 |  | TRANSPORTE DE MATERIAL GRANULAR PARA DISTANCIAS <1KM | 139d | 2024-01-14 | 2024-05-31 | A6900 SS | 3d | 0d | HH [1112 h] |  |
| A7420 |  | TRANSPORTE DE MATERIAL GRANULAR PARA DISTANCIAS >1KM | 139d | 2024-01-14 | 2024-05-31 | A6830 SS | 3d | 0d | HH [1112 h] |  |
| A7430 |  | TRANSPORTE DE ROCA PARA DISTANCIAS <1KM | 123d | 2024-01-30 | 2024-05-31 | A6940 SS | 3d | 0d | HH [984 h] |  |
| A7440 |  | TRANSPORTE DE ROCA PARA DISTANCIAS >1KM | 123d | 2024-01-30 | 2024-05-31 | A6940 SS | 3d | 0d | HH [984 h] |  |

| ID | WBS | Activity | Duration | Start | Finish | Predecessors | Total float | Free float | Resources |
| --- | --- | --- | --- | --- | --- | --- | --- | --- | --- |
|  | 2 | **OBRAS DE ARTE (REBOSES)** |  | 2024-03-08 | 2024-05-09 |  |  |  |  |
|  | 1 | **ESTRUCTURA DE REBOSE** |  | 2024-03-08 | 2024-05-09 |  |  |  |  |
|  | 1 | **MOVIMIENTO DE TIERRAS** |  | 2024-03-08 | 2024-03-25 |  |  |  |  |
| A2770 |  | DESBROCE Y LIMPIEZA | 2d | 2024-03-08 | 2024-03-09 | A7160 | 25d | 0d | HH [16 h] |
| A2780 |  | EXCAVACIÓN ESTRUCTURAL BAJO AGUA | 8d | 2024-03-10 | 2024-03-17 | A2770 | 25d | 0d | HH [64 h] |
| A2840 |  | CAMA DE ARENA | 8d | 2024-03-18 | 2024-03-25 | A2780 | 25d | 0d | HH [64 h] |
| A2850 |  | RELLENO ESTRUCTURAL PARA OBRAS DE ARTE CON MATERIAL DE PRÉSTAMO | 3d | 2024-03-22 | 2024-03-24 | A2900 SS+2d | 25d | 0d | HH [24 h] |
|  | 4 | **TUBERIAS** |  | 2024-03-19 | 2024-03-23 |  |  |  |  |
| A2890 |  | SUMINISTRO E INSTALACIÓN DE TUBERÍA HDPE DN800 mm | 2d | 2024-03-19 | 2024-03-20 | A2840 SS+1d | 25d | 0d | HH [16 h] |
| A2900 |  | SUMINISTRO E INSTALACIÓN DE TUBERÍA HDPE DN1000 mm | 4d | 2024-03-20 | 2024-03-23 | A2890 SS+1d | 25d | 0d | HH [32 h] |
|  | 2 | **OBRAS DE CONCRETO** |  | 2024-03-25 | 2024-05-09 |  |  |  |  |
| A2790 |  | CONCRETO f'c=100 kg/cm2 | 7d | 2024-03-25 | 2024-03-31 | A2850 | 25d | 0d | HH [56 h] |
| A2830 |  | ACERO DE REFUERZO fy=4200 kg/cm2 | 10d | 2024-04-01 | 2024-04-10 | A2790 | 25d | 0d | HH [80 h] |
| A2820 |  | ENCOFRADO Y DESENCOFRADO RECTO | 33d | 2024-04-02 | 2024-05-04 | A2830 SS+1d | 25d | 0d | HH [264 h] |
| A2800 |  | CONCRETO f'c=280 kg/cm2 | 33d | 2024-04-07 | 2024-05-09 | A2830 SS+5d, A2820 SS+5d | 25d |  | HH [264 h] |
|  | 3 | **INTERFERENCIAS** |  | 2024-03-11 | 2024-05-14 |  |  |  |  |
|  | 3 | **AFECTACIÓN A ESTRUCTURAS PRIVADAS** |  | 2024-03-11 | 2024-05-14 |  |  |  |  |
|  | 3 | **REUBICACIÓN DE INTERFERENCIAS** |  | 2024-03-11 | 2024-03-30 |  |  |  |  |
| A7560 |  | DEMOLICIÓN DE INTERFERENCIAS SIMA | 10d | 2024-03-11 | 2024-03-20 | A7170 | 20d | 0d | HH [80 h] |
| A7570 |  | ELIMINACIÓN DE INTERFERENCIAS SIMA | 10d | 2024-03-21 | 2024-03-30 | A7560 | 20d | 0d | HH [80 h] |
|  | 1 | **MOVIMIENTO DE TIERRAS** |  | 2024-03-26 | 2024-05-14 |  |  |  |  |
| A6750 |  | EXCAVACIÓN ESTRUCTURAL PARA OBRAS DE ARTE | 30d | 2024-03-26 | 2024-04-24 | A7570 SS+5d | 20d | 0d | HH [240 h] |
| A6760 |  | RELLENO ESTRUCTURAL PARA OBRAS DE ARTE, CON MATERIAL PROPIO | 10d | 2024-05-05 | 2024-05-14 | A6810 | 20d |  | HH [80 h] |
|  | 2 | **REPOSICIÓN DE TUBERÍAS DE PASO** |  | 2024-04-25 | 2024-05-04 |  |  |  |  |
| A6770 |  | REPOSICIÓN DE TUBERÍAS DE HDPE DE 4" | 5d | 2024-04-25 | 2024-04-29 | A6750 | 20d | 0d | HH [40 h] |
| A6790 |  | REPOSICIÓN DE TUBERÍAS DE HDPE DE 6" | 5d | 2024-04-30 | 2024-05-04 | A6770 | 20d | 0d | HH [40 h] |
| A6810 |  | REPOSICIÓN DE TUBERÍAS DE HDPE DE 8" | 5d | 2024-04-30 | 2024-05-04 | A6790 SS | 20d | 0d | HH [40 h] |

| ID | WBS | Activity | Duration | Start | Finish | Predecessors | Total float | Free float | Resources | Filtro |
| --- | --- | --- | --- | --- | --- | --- | --- | --- | --- | --- |
|  | 4 | **CANAL A REPONER DE SECCIÓN RECTANGULAR** |  | 2024-04-10 | 2024-05-08 |  |  |  |  |  |
|  | 1 | **MOVIMIENTO DE TIERRAS** |  | 2024-04-10 | 2024-04-28 |  |  |  |  |  |
| A3540 |  | DEMOLICION DE ESTRUCTURAS EXISTENTE | 11d | 2024-04-10 | 2024-04-20 | A7040 SS | 26d | 0d | HH [88 h] |  |
| A3460 |  | RELLENO ESTRUCTURAL PARA OBRAS DE ARTE CON MATERIAL DE PRÉSTAMO | 14d | 2024-04-15 | 2024-04-28 | A3540 SS+5d | 26d | 0d | HH [112 h] |  |
| A3470 |  | ELIMINACIÓN DE PRODUCTOS DE DEMOLICIÓN DE OBRAS DE CONCRETO | 10d | 2024-04-19 | 2024-04-28 | A3540 SS+2d, A3550 SS | 36d |  | HH [80 h] |  |
| A3550 |  | EXCAVACIÓN EN TERRENO NATURAL CON EQUIPO | 3d | 2024-04-19 | 2024-04-21 | A3540 FF+1d | 36d | 0d | HH [24 h] |  |
|  | 2 | **OBRAS DE CONCRETO** |  | 2024-04-20 | 2024-05-08 |  |  |  |  |  |
| A3480 |  | CONCRETO f'c=100 kg/cm2 | 3d | 2024-04-20 | 2024-04-22 | A3460 SS+5d | 26d | 0d | HH [24 h] |  |
| A3490 |  | CONCRETO f'c=280 kg/cm2 | 18d | 2024-04-21 | 2024-05-08 | A3510 FF | 26d | 0d | HH [144 h] |  |
| A3520 |  | ACERO DE REFUERZO fy=4200 kg/cm2 | 14d | 2024-04-23 | 2024-05-06 | A3480 | 26d | 0d | HH [112 h] |  |
| A3530 |  | SELLO DE JUNTAS CON WATER STOP 6" | 5d | 2024-04-23 | 2024-04-27 | A3490 SS+2d | 37d |  | HH [40 h] |  |
| A3510 |  | ENCOFRADO Y DESENCOFRADO | 10d | 2024-04-29 | 2024-05-08 | A3520 SS+6d, A3480 | 26d | 0d | HH [80 h] |  |
|  | 1 | **CANAL A REPONER DE SECCIÓN TRAPEZOIDAL** |  | 2024-04-10 | 2024-05-09 |  |  |  |  |  |
|  | 1 | **MOVIMIENTO DE TIERRAS** |  | 2024-04-10 | 2024-04-25 |  |  |  |  |  |
| A7470 |  | DEMOLICION DE ESTRUCTURAS EXISTENTE | 6d | 2024-04-10 | 2024-04-15 | A7040 SS | 25d | 0d | HH [48 h] |  |
| A7480 |  | EXCAVACIÓN EN TERRENO NATURAL CON EQUIPO | 3d | 2024-04-14 | 2024-04-16 | A7470 FF+1d | 25d | 0d | HH [24 h] |  |
| A7490 |  | ELIMINACIÓN DE PRODUCTOS DE DEMOLICIÓN DE OBRAS DE CONCRETO | 10d | 2024-04-16 | 2024-04-25 | A7470 SS+2d, A7480 SS+2d | 25d | 0d | HH [80 h] |  |
| A7500 |  | RELLENO ESTRUCTURAL PARA OBRAS DE ARTE CON MATERIAL DE PRÉSTAMO | 2d | 2024-04-18 | 2024-04-19 | A7470 SS+5d, A7490 SS+2d | 25d | 0d | HH [16 h] |  |
|  | 2 | **OBRAS DE CONCRETO** |  | 2024-04-20 | 2024-05-09 |  |  |  |  |  |
| A7520 |  | ENCOFRADO Y DESENCOFRADO CERCHAS DE MADERAACERO DE REFUERZO fy=4200 kg/cm2 | 5d | 2024-04-20 | 2024-04-24 | A7500 | 25d | 0d | HH [40 h] |  |
| A7530 |  | ENCOFRADO Y DESENCOFRADO | 12d | 2024-04-26 | 2024-05-07 | A7520 SS+6d | 25d | 0d | HH [96 h] |  |
| A7540 |  | CONCRETO f'c=280 kg/cm2 | 12d | 2024-04-26 | 2024-05-07 | A7530 FF | 25d | 0d | HH [96 h] |  |
| A7550 |  | SELLO DE JUNTAS CON WATER STOP 6" | 12d | 2024-04-28 | 2024-05-09 | A7540 SS+2d | 25d |  | HH [96 h] |  |
|  | 4 | **PROGRAMA DE CIERRE DE OBRA** |  | 2023-12-21 | 2024-06-01 |  |  |  |  |  |
| A1780 |  | ACONDICIONAMIENTO DE DEPOSITOS DE MATERIALES EXCEDENTES (DME) | 163d | 2023-12-21 | 2024-05-31 | A1220 SS | 3d | 0d | HH [1304 h] |  |
| A1790 |  | RESTAURACIÓN DE ÁREAS DE INSTALACIONES PROVISIONALES | 13d | 2024-05-19 | 2024-05-31 | A1780 FF | 3d | 0d | HH [104 h] |  |
| A1770 |  | FIN DE OBRAS | 0d | 2024-06-01 | 2024-06-01 | A1220, A7450, A7460, A6830, A7420, A7430, A7440, A7390, A7400, A1790, A1100, A5850, A7280, A7060, A7200, A7210 SF, A7410 | 3d |  |  | Excavación |
